# Project 2006-01 System Personnel Training

Schedule from MS Project, 2004-11-01 to 2010-02-02, A marks actual dates.
Proposed Work Plan
NERC

## Calendars

- Standard: Mon-Sun 08:00-12:00, 13:00-17:00. Exceptions (off unless hours are given): 2007-09-01 08:00-12:00, 13:00-17:00, 2008-06-15 08:00-12:00, 13:00-17:00, 2008-11-01 08:00-12:00, 13:00-17:00.

## Schedule

| ID | WBS | Task | Type | Duration | Start | Finish | Predecessors | Complete | Remaining | Baseline start | Baseline finish | Baseline duration | Total slack | Constraint |
| --- | --- | --- | --- | --- | --- | --- | --- | --- | --- | --- | --- | --- | --- | --- |
| 1 | 1 | **NERC Standard Development for Project 2006-01** |  | 1393d | 2004-11-01 A | 2008-08-24 |  | 74% | 367.71d | 2004-11-01 | 2008-05-21 | 929d? | 0d |  |
| 2 | 1.1 | **SAR Development and Finalization** |  | 558d | 2004-11-01 A | 2006-05-12 A |  | 100% |  | 2004-11-01 | 2006-05-12 | 400d |  |  |
| 3 | 1.1.1 | Step 1 - Draft SAR |  | 25d | 2004-11-01 A | 2004-11-25 A |  | 100% |  | 2004-11-01 | 2004-12-03 | 25d |  | start no earlier than 2004-11-01 |
| 4 | 1.1.2 | Step 2a- Solicit Public Comment on SAR |  | 24d | 2004-12-07 A | 2004-12-30 A |  | 100% |  | 2004-12-07 | 2005-01-07 | 24d |  | start no earlier than 2004-12-07 |
| 5 | 1.1.3 | Step 2b - Address Comments & Revise SAR |  | 60d | 2004-12-31 A | 2005-02-28 A | 4 | 100% |  | 2005-01-10 | 2005-04-01 | 60d |  |  |
| 8 | 1.1.4 | Step 3 - Authorization to Proceed to Standard Development |  | 1d | 2006-05-12 A | 2006-05-12 A | 23 | 100% |  | 2006-05-12 | 2006-05-12 | 1d |  | start no earlier than 2006-05-12 |
| 9 | 1.2 | **Standard Development and Implementation** |  | 854d | 2006-04-24 A | 2008-08-24 |  | 67% | 282.55d | 2006-04-17 | 2008-05-21 | 549d? | 0d |  |
| 10 | 1.2.1 | Step 4 - Appoint Standard Drafting Team |  | 50d | 2006-04-24 A | 2006-06-12 A | 8FS-20d | 100% |  | 2006-04-17 | 2006-06-22 | 49d |  | finish no earlier than 2006-06-12 |
| 11 | 1.2.2 | Step 5 - Draft Standard R1 |  | 68d | 2006-06-13 A | 2006-08-19 A | 10 | 100% |  | 2006-06-23 | 2006-09-26 | 68d |  |  |
| 12 | 1.2.3 | Step 6a - Solicit Public Comment on R1 |  | 30d | 2006-09-27 A | 2006-10-26 A | 11 | 100% |  | 2006-09-27 | 2006-10-26 | 22d |  | start no earlier than 2006-09-27 |
| 13 | 1.2.4 | Step 6b - Address Comments and Redraft R2 |  | 208d | 2007-01-19 A | 2007-08-14 A | 12 | 100% |  | 2006-10-27 | 2007-08-09 | 205d |  | finish no earlier than 2007-08-14 |
| 14 | 1.2.5 | Step 6c - Solicit Public Comment on R2 |  | 45d | 2007-08-15 A | 2007-09-28 A | 13 | 100% |  | 2007-08-10 | 2007-10-10 | 45d? |  | start no earlier than 2007-08-15 |
| 15 | 1.2.6 | Step 6d - Address Comments and Redraft R3 |  | 60d | 2007-11-12 A | 2008-01-10 | 14FS+42d | 80% | 12d |  |  |  | 227d | start no earlier than 2007-11-12 |
| 16 | 1.2.7 | Step 6e - Solicit Public Comment on R3 |  | 30d | 2008-01-28 | 2008-02-26 |  |  |  |  |  |  | 0d | start no earlier than 2008-01-28 |
| 18 | 1.2.8 | Step 9 - Ballot/Reballot |  | 90d | 2008-04-27 | 2008-07-25 | 24, 16 |  |  | 2007-10-11 | 2008-01-02 | 60d | 0d | finish no earlier than 2008-07-07 |
| 19 | 1.2.9 | Step 10 - Submit to BOT Adoption |  | 30d | 2008-07-26 | 2008-08-24 | 18 |  |  | 2008-01-03 | 2008-02-13 | 30d | 0d |  |
| 21 | 1.3 | Step 2c - SAR Draft 2 Posted for Comment |  | 245d | 2008-07-24 | 2009-06-30 | 5FS+2d |  |  |  |  |  | 0d |  |
| 23 | 1.4 | Step 2d - Address Comments & Revise SAR |  | 90d | 2009-08-05 | 2009-12-08 | 21FS+1d |  |  |  |  |  | 0d |  |
| 24 | 1.5 | Step 6f - Address Comments on R3 |  | 40d | 2009-12-09 | 2010-02-02 | 16 |  |  |  |  |  | 0d |  |
| 25 | 1.6 | NERC BOT Adopt | milestone | 0d | 2010-02-02 | 2010-02-02 | 19 |  |  |  |  |  | 0d |  |
